# AB-01 - met lichte binnenwanden

Schedule from MS Project, 2003-01-12 to 2003-02-25, status date 2003-01-08.
BAM Nelissen Van Egteren

## Calendars

- ALLEEN WERKDAGEN: Mon-Fri 08:30-12:30, 13:00-17:00; Sat-Sun off. Exceptions (off unless hours are given): 2003-01-11 to 2003-01-12 08:30-12:30, 13:00-17:00, 2003-01-18 to 2003-01-19 08:30-12:30, 13:00-17:00, 2003-01-25 to 2003-01-26 08:30-12:30, 13:00-17:00, 2003-02-01 to 2003-02-02 08:30-12:30, 13:00-17:00, 2003-02-08 to 2003-02-09 08:30-12:30, 13:00-17:00, 2003-02-15 to 2003-02-16 08:30-12:30, 13:00-17:00, 2003-02-22 to 2003-02-23 08:30-12:30, 13:00-17:00.

## Schedule

| ID | WBS | Task | Duration | Start | Finish | Predecessors | Total slack | Free slack |
| --- | --- | --- | --- | --- | --- | --- | --- | --- |
| 1 | 1 | **AFBOUWFASE** | 45d | 2003-01-12 | 2003-02-25 |  | 0d |  |
| 2 | 1.1 | **inbouwfase** | 18d | 2003-01-12 | 2003-01-29 |  | 0d |  |
| 3 | 1.1.1 | standleidingen loodg+ventilatie | 5d | 2003-01-12 | 2003-01-16 |  | 0d |  |
| 4 | 1.1.2 | vloerleidingen CV | 5d | 2003-01-13 | 2003-01-17 | 3SS+1d | 0d |  |
| 5 | 1.1.3 | trappen stellen | 5d | 2003-01-14 | 2003-01-18 | 4SS+1d | 0d |  |
| 6 | 1.1.4 | dekvloer aanbrengen | 5d | 2003-01-15 | 2003-01-19 | 5SS+1d | 0d |  |
| 7 | 1.1.5 | binnenwand profielen stellen | 5d | 2003-01-20 | 2003-01-24 | 6SS+5d | 0d |  |
| 8 | 1.1.6 | binnenwanden plaatsen | 5d | 2003-01-21 | 2003-01-25 | 7SS+1d | 0d |  |
| 9 | 1.1.7 | binnenwand sleuven fraisen | 5d | 2003-01-23 | 2003-01-27 | 8SS+2d | 0d |  |
| 10 | 1.1.8 | electradozen+bedrading | 5d | 2003-01-24 | 2003-01-28 | 9SS+1d | 0d |  |
| 11 | 1.1.9 | water+riolering leidingen | 5d | 2003-01-25 | 2003-01-29 | 10SS+1d | 0d |  |
| 12 | 1.2 | **afwerkingsfase** | 23d | 2003-01-26 | 2003-02-17 |  | 0d |  |
| 13 | 1.2.1 | binnenwanden afwerken | 5d | 2003-01-26 | 2003-01-30 | 11SS+1d | 0d |  |
| 14 | 1.2.2 | stucwerk+behangklaar maken | 5d | 2003-01-27 | 2003-01-31 | 13SS+1d | 0d |  |
| 15 | 1.2.3 | wandtegels lijmen | 5d | 2003-01-28 | 2003-02-01 | 14SS+1d | 0d |  |
| 16 | 1.2.4 | spuitwerp wanden+plafonds | 5d | 2003-01-30 | 2003-02-03 | 15SS+2d | 0d |  |
| 17 | 1.2.5 | vloertegels zetten | 5d | 2003-02-02 | 2003-02-06 | 16SS+3d | 0d |  |
| 18 | 1.2.6 | binnenschilderwerk | 5d | 2003-02-11 | 2003-02-15 | 26SS+2d | 0d |  |
| 19 | 1.2.7 | behangwerk aanbrengen | 5d | 2003-02-13 | 2003-02-17 | 18SS+2d | 0d |  |
| 20 | 1.3 | **uitrustingsfase** | 17d | 2003-02-04 | 2003-02-20 |  | 0d |  |
| 21 | 1.3.1 | binnendeurkozijnen monteren | 5d | 2003-02-04 | 2003-02-08 | 17SS+2d | 0d |  |
| 22 | 1.3.2 | radiatoren monteren+vullen | 5d | 2003-02-05 | 2003-02-09 | 21SS+1d | 0d |  |
| 23 | 1.3.3 | electra+meterkast monteren | 5d | 2003-02-06 | 2003-02-10 | 22SS+1d | 0d |  |
| 24 | 1.3.4 | mechanische ventilatie mont. | 5d | 2003-02-07 | 2003-02-11 | 23SS+1d | 0d |  |
| 25 | 1.3.5 | sanitair+kranen monteren | 5d | 2003-02-08 | 2003-02-12 | 24SS+1d | 0d |  |
| 26 | 1.3.6 | aftimmeren plinten+buitendeur | 5d | 2003-02-09 | 2003-02-13 | 25SS+1d | 0d |  |
| 27 | 1.3.7 | binnendeuren afhangen | 5d | 2003-02-15 | 2003-02-19 | 19SS+2d | 5d | 0d |
| 28 | 1.3.8 | keukenblok stellen | 5d | 2003-02-16 | 2003-02-20 | 27SS+1d | 5d |  |

| ID | WBS | Task | Duration | Start | Finish | Predecessors | Total slack |
| --- | --- | --- | --- | --- | --- | --- | --- |
| 29 | 1.4 | **opleveringsfase** | 11d | 2003-02-15 | 2003-02-25 |  | 0d |
| 30 | 1.4.1 | schoonmaken woning | 5d | 2003-02-15 | 2003-02-19 | 19SS+2d | 0d |
| 31 | 1.4.2 | vooropnemen gebreken | 5d | 2003-02-17 | 2003-02-21 | 30SS+2d | 0d |
| 32 | 1.4.3 | herstelwerkzaamheden | 5d | 2003-02-19 | 2003-02-23 | 31SS+2d | 0d |
| 33 | 1.4.4 | opleveren woning | 5d | 2003-02-21 | 2003-02-25 | 32SS+2d | 0d |
